# EA with FONSI - Anticipated Primavera 6.0 Schedule

Schedule from Primavera P6, 2026-01-01 to 2030-02-27, data date 2026-01-01.

## Calendars

- Standard: Mon-Fri 08:00-12:00, 13:00-17:00; Sat-Sun off.

## Schedule

| ID | WBS | Activity | Type | Duration | Start | Finish | Predecessors | Total float | Free float | Constraint | user_text1 |
| --- | --- | --- | --- | --- | --- | --- | --- | --- | --- | --- | --- |
|  | 1 | **PLANNING & PRE-PD&E ACTIVITIES** |  |  | 2026-01-01 | 2029-03-12 |  |  |  |  |  |
| 02 |  | START - Pass the Torch from Planning to PD&E / ETDM | resource dependent | 1d | 2026-01-01 | 2026-01-01 |  | 0d |  | start on or after 2026-01-01 | 703 |
|  | 2 | **ETDM PLANNING SCREEN** |  |  | 2026-01-02 | 2026-05-20 |  |  |  |  |  |
| 04 |  | ETDM Planning Screen PED | resource dependent | 20d | 2026-01-02 | 2026-01-29 | 02 | 0d |  |  |  |
| 05 |  | ETMD Planning Screen Purpose and Need | resource dependent | 20d | 2026-01-02 | 2026-01-29 | 02 | 0d |  |  |  |
| 06 |  | ETDM Planning Screen Start | resource dependent | 32d | 2026-01-30 | 2026-03-16 | 04, 05 | 0d |  |  |  |
| 07 |  | ETDM Planning Screen Responses | resource dependent | 45d | 2026-03-17 | 2026-05-18 | 06 | 0d |  |  |  |
| 08 |  | ETDM Planning Summary Screen Report Published | resource dependent | 1d | 2026-05-19 | 2026-05-19 | 07 | 0d |  |  |  |
| 09 |  | Assign PD&E Project Manager | resource dependent | 1d | 2026-05-20 | 2026-05-20 | 08 | 19d |  |  | 704 |
|  | 4 | **ETDM PROGRAMMING SCREEN** |  |  | 2026-05-20 | 2029-03-12 |  |  |  |  |  |
| 11 |  | ETDM Programming Pre-Screen PED + Purpose and Need | resource dependent | 20d | 2026-05-20 | 2026-06-16 | 08 | 0d |  |  | 746 |
| 12 |  | Approval: ETDM Programming Pre-Screen PED + Purpose and Need | resource dependent | 0d | 2026-06-17 | 2026-06-17 | 11 FF | 0d |  |  |  |
| 13 |  | ETDM Programming Screen Start | resource dependent | 32d | 2026-06-17 | 2026-07-30 | 09, 12 | 0d |  |  | 700 |
| 14 |  | Advance Notification | resource dependent | 32d | 2026-06-17 | 2026-07-30 | 09, 12 | 0d |  |  | 224 |
| 15 |  | ETDM Programming Screen Responses | resource dependent | 44d | 2026-07-31 | 2026-09-30 | 13, 14 | 0d |  |  |  |
| 16 |  | ETDM DRAFT Programming Screen Summary Report (w assumed Class of Action) | resource dependent | 1d | 2026-10-01 | 2026-10-01 | 15 | 0d |  |  |  |
| 17 |  | ETDM FINAL Programming Screen Summary Report Published (w final COA) | resource dependent | 10d | 2029-02-27 | 2029-03-12 | 16, 150 | 29d | 0d |  | 702 |
|  | 5 | **DEVELOP SCOPE AND SCHEDULE** |  |  | 2026-10-02 | 2026-10-29 |  |  |  |  |  |
| 19 |  | Initial PD&E Phase Scope (Stage 1) and Schedule Complete | resource dependent | 20d | 2026-10-02 | 2026-10-29 | 16 | 0d |  |  | 164 |
|  | 6 | **PROCUREMENT PHASE** |  |  | 2026-10-30 | 2027-05-05 |  |  |  |  |  |
| 21 |  | PD&E Phase Advertisement | resource dependent | 1d | 2026-10-30 | 2026-10-30 | 19 | 0d |  |  | 705 |
| 22 |  | Procurement Phase | resource dependent | 120d | 2026-11-02 | 2027-04-16 | 21 | 0d |  |  |  |
| 23 |  | Final PD&E Phase Scope Phase (Stage 3) | resource dependent | 11d | 2027-04-19 | 2027-05-03 | 22 | 0d |  |  | 164 |
| 24 |  | PD&E Phase Contract Executed | resource dependent | 1d | 2027-05-04 | 2027-05-04 | 23 | 0d |  |  | 239 |
| 25 |  | Notice to Proceed | resource dependent | 1d | 2027-05-05 | 2027-05-05 | 23, 24 | 0d |  | start on or after 2016-04-01 | 234 |

| ID | WBS | Activity | Type | Duration | Start | Finish | Predecessors | Total float | Free float | Constraint | user_text1 |
| --- | --- | --- | --- | --- | --- | --- | --- | --- | --- | --- | --- |
|  | 2 | **PD&E PHASE** |  |  | 2027-05-05 | 2030-02-27 |  |  |  |  |  |
|  | 1 | **PROJECT MANAGEMENT PHASE** |  |  | 2027-05-05 | 2029-03-13 |  |  |  |  |  |
| 28 |  | Anticipated PD&E Phase Start (Environmental Assessment) | resource dependent | 1d | 2027-05-05 | 2027-05-05 | 25 FS-1d | 0d |  |  | 777 |
| 29 |  | Prepare Project Management Plan | resource dependent | 5d | 2027-05-06 | 2027-05-12 | 28 | 0d |  |  |  |
| 30 |  | Review Local Plans to ensure Planning Consistency | resource dependent | 3d | 2027-05-06 | 2027-05-10 | 28 | 2d |  |  |  |
| 31 |  | Prepare QC Plan | resource dependent | 5d | 2027-05-06 | 2027-05-12 | 28 | 0d |  |  |  |
| 32 |  | Project Kickoff Meeting with FDOT | resource dependent | 1d | 2027-05-13 | 2027-05-13 | 29, 31, 30 | 0d |  |  |  |
| 33 |  | EA Start: after COA Determination by OEM | resource dependent | 0d | 2029-03-13 | 2029-03-13 | 51, 17 | 245d |  |  |  |
|  | 2 | **PUBLIC INVOLVEMENT** |  |  | 2027-05-06 | 2029-10-29 |  |  |  |  |  |
| 35 |  | Prepare Public Involvement Plan | resource dependent | 20d | 2027-05-06 | 2027-06-02 | 28 | 85d | 31d |  | 748 |
| 36 |  | Public Involvement Data Collection | resource dependent | 45d | 2027-05-14 | 2027-07-15 | 32 | 54d | 0d |  |  |
|  | 3 | **Prepare for Public Kickoff Meeting** |  |  | 2027-07-16 | 2027-09-27 |  |  |  |  |  |
| 38 |  | Site Review | resource dependent | 1d | 2027-07-16 | 2027-07-16 | 36, 35 | 54d | 0d |  | 365 |
| 39 |  | Newsletter | resource dependent | 20d | 2027-07-19 | 2027-08-13 | 38 | 54d | 0d |  |  |
| 40 |  | Prepare FAR/ FDOT Website Notice (Newspaper optional) | resource dependent | 20d | 2027-07-19 | 2027-08-13 | 38 | 54d | 0d |  |  |
| 41 |  | Prepare Elected/Appointed/Property Owner Notifications | resource dependent | 20d | 2027-07-19 | 2027-08-13 | 38 | 54d | 0d |  |  |
| 42 |  | Presentation/Display Material Review | resource dependent | 20d | 2027-08-16 | 2027-09-10 | 41, 39, 40 | 54d | 0d | start on or after 2026-08-10 |  |
| 43 |  | Public Kickoff Meeting | resource dependent | 1d | 2027-09-13 | 2027-09-13 | 69, 42 | 54d | 0d |  | 292 |
| 44 |  | Public Comment Period | resource dependent | 10d | 2027-09-14 | 2027-09-27 | 43 | 54d | 0d |  |  |
|  | 4 | **Prepare for Public Meeting / Workshop** |  |  | 2028-03-06 | 2028-08-14 |  |  |  |  |  |
| 46 |  | Site Review | resource dependent | 1d | 2028-03-06 | 2028-03-06 | 110 FS-60d, 44 | 64d | 0d |  | 365 |
| 47 |  | Newsletter | resource dependent | 25d | 2028-03-07 | 2028-04-10 | 46 | 64d | 0d |  |  |
| 48 |  | Prepare FAR/ FDOT Website Notice (Newspaper optional) | resource dependent | 20d | 2028-03-07 | 2028-04-03 | 46 | 69d | 5d |  |  |
| 49 |  | Prepare Elected/Appointed/Property Owner Notifications | resource dependent | 20d | 2028-03-07 | 2028-04-03 | 46 | 69d | 5d |  |  |
| 50 |  | Presentation/Display Material Review | resource dependent | 15d | 2028-04-11 | 2028-05-01 | 46, 47, 48, 49 | 64d |  |  |  |
| 51 |  | Public Meeting / Workshop | resource dependent | 1d | 2028-07-31 | 2028-07-31 | 110 FS+5d, 50, 89 | 0d |  |  | 711 |
| 52 |  | Public Comment Period | resource dependent | 10d | 2028-08-01 | 2028-08-14 | 51 | 0d |  |  |  |

| ID | WBS | Activity | Type | Duration | Start | Finish | Predecessors | Total float | Free float | user_text1 |
| --- | --- | --- | --- | --- | --- | --- | --- | --- | --- | --- |
|  | 5 | **Prepare for Public Hearing** |  |  | 2029-05-08 | 2029-10-29 |  |  |  |  |
| 54 |  | Site Review | resource dependent | 20d | 2029-05-08 | 2029-06-04 | 52, 154 | 44d | 0d | 366 |
| 55 |  | Newsletter | resource dependent | 20d | 2029-06-05 | 2029-07-02 | 54 | 44d | 0d |  |
| 56 |  | Prepare Newspaper/ FAR/ FDOT Website Notice | resource dependent | 20d | 2029-06-05 | 2029-07-02 | 54 | 44d | 0d |  |
| 57 |  | Prepare Elected/Appointed/Property Owner Notifications | resource dependent | 20d | 2029-06-05 | 2029-07-02 | 54 | 44d | 0d |  |
| 58 |  | Presentation/Display Material Review | resource dependent | 15d | 2029-07-03 | 2029-07-23 | 54, 55, 56, 57 | 44d |  |  |
| 59 |  | Document Available for Public Review | resource dependent | 15d | 2029-09-24 | 2029-10-12 | 58, 160, 94 | 0d |  |  |
| 60 |  | Public Hearing | resource dependent | 1d | 2029-10-15 | 2029-10-15 | 59, 58 | 0d |  | 262 |
| 61 |  | Public Comment Period | resource dependent | 10d | 2029-10-16 | 2029-10-29 | 60 | 0d |  |  |
|  | 3 | **ENGINEERING ANALYSIS** |  |  | 2027-05-06 | 2029-06-15 |  |  |  |  |
|  | 1 | **Data Collection** |  |  | 2027-05-14 | 2027-06-24 |  |  |  |  |
| 64 |  | Roadway Data Collection | resource dependent | 30d | 2027-05-14 | 2027-06-24 | 32 | 121d | 0d |  |
| 65 |  | Drainage Data Collection | resource dependent | 30d | 2027-05-14 | 2027-06-24 | 32 | 121d | 0d |  |
| 66 |  | Bridge Data Collection | resource dependent | 30d | 2027-05-14 | 2027-06-24 | 32 | 121d | 0d |  |
| 67 |  | Geotechnical Data Collection | resource dependent | 30d | 2027-05-14 | 2027-06-24 | 32 | 121d | 0d |  |
| 68 |  | Topographic Survey and ROW Mapping | resource dependent | 30d | 2027-05-14 | 2027-06-24 | 32 | 121d | 0d |  |
| 69 |  | Prepare Base Map | resource dependent | 30d | 2027-05-14 | 2027-06-24 | 32 | 110d | 0d |  |
|  | 2 | **Traffic Analysis** |  |  | 2027-05-14 | 2028-02-04 |  |  |  |  |
| 71 |  | Traffic Methodology Meeting | resource dependent | 1d | 2027-05-14 | 2027-05-14 | 32 | 0d |  |  |
| 72 |  | Traffic Methodology Memorandum | resource dependent | 10d | 2027-05-17 | 2027-05-28 | 71 | 0d |  |  |
| 73 |  | Forecasting and Analysis | resource dependent | 50d | 2027-05-31 | 2027-08-06 | 72 | 0d |  |  |
| 74 |  | Prepare Traffic Projections | resource dependent | 40d | 2027-08-09 | 2027-10-01 | 73 | 0d |  |  |
| 75 |  | Prepare Capacity Analysis | resource dependent | 40d | 2027-10-04 | 2027-11-26 | 74 | 0d |  |  |
| 76 |  | Draft Traffic Analysis Report | resource dependent | 30d | 2027-11-29 | 2028-01-07 | 75 | 0d |  |  |
| 77 |  | District Review - Draft Traffic Analysis Report | resource dependent | 15d | 2028-01-10 | 2028-01-28 | 76 | 40d | 0d |  |
| 78 |  | Final Traffic Analysis Report | resource dependent | 5d | 2028-01-31 | 2028-02-04 | 77 | 40d | 0d | 757 |

| ID | WBS | Activity | Type | Duration | Start | Finish | Predecessors | Total float | Free float | user_text1 |
| --- | --- | --- | --- | --- | --- | --- | --- | --- | --- | --- |
|  | 3 | **Interchange Access Request** |  |  | 2027-05-06 | 2028-10-16 |  |  |  |  |
| 80 |  | Initiate IAR | resource dependent | 1d | 2027-05-06 | 2027-05-06 | 28 | 131d | 0d |  |
| 81 |  | Prepare MLOU | resource dependent | 10d | 2027-05-07 | 2027-05-20 | 80 | 131d | 0d |  |
| 82 |  | DIRC/SPO Review of MLOU | resource dependent | 15d | 2027-05-21 | 2027-06-10 | 81 | 131d | 0d |  |
| 83 |  | FHWA Review of MLOU | resource dependent | 20d | 2027-06-11 | 2027-07-08 | 82 | 131d |  |  |
| 84 |  | Develop Alternatives | resource dependent | 40d | 2028-01-10 | 2028-03-03 | 83, 76, 44 | 0d |  |  |
| 85 |  | Perform Operational Analysis | resource dependent | 30d | 2028-03-06 | 2028-04-14 | 84 | 0d |  |  |
| 86 |  | Prepare Preliminary IAR | resource dependent | 30d | 2028-04-17 | 2028-05-26 | 85 | 0d |  |  |
| 87 |  | DIRC/SPO Review of Preliminary IAR | resource dependent | 10d | 2028-05-29 | 2028-06-09 | 86 | 0d |  |  |
| 88 |  | Comment Resolution & Update Preliminary IAR | resource dependent | 15d | 2028-06-12 | 2028-06-30 | 87 | 0d |  |  |
| 89 |  | FHWA Review of Preliminary IAR | resource dependent | 20d | 2028-07-03 | 2028-07-28 | 88 | 0d |  |  |
| 90 |  | Prepare Final IAR | resource dependent | 20d | 2028-07-31 | 2028-08-25 | 89 | 244d | 0d |  |
| 91 |  | DIRC/SPO Review of Final IAR | resource dependent | 10d | 2028-08-28 | 2028-09-08 | 90 | 244d | 0d |  |
| 92 |  | Comment Resolution & Update Final IAR | resource dependent | 5d | 2028-09-11 | 2028-09-15 | 91 | 244d | 0d |  |
| 93 |  | FHWA/SPO Review of IAR | resource dependent | 20d | 2028-09-18 | 2028-10-13 | 92 | 244d | 0d |  |
| 94 |  | Safety, Operations & Engineering Approval | resource dependent | 1d | 2028-10-16 | 2028-10-16 | 93 | 244d |  |  |
|  | 4 | **Alternative Analysis** |  |  | 2027-06-25 | 2029-06-15 |  |  |  |  |
| 097 |  | Structure Analysis | resource dependent | 40d | 2027-06-25 | 2027-08-19 | 64, 65, 66, 67, 68, 69 | 121d | 67d |  |
| 099 |  | Complete Streets/Multi Modal Analysis | resource dependent | 40d | 2027-06-25 | 2027-08-19 | 64, 65, 66, 67, 68 | 201d | 161d |  |
| 102 |  | Access Management Analysis | resource dependent | 40d | 2027-06-25 | 2027-08-19 | 69 | 201d | 161d |  |
| 096 |  | Roadway Analysis | resource dependent | 40d | 2027-09-28 | 2027-11-22 | 64, 65, 66, 67, 68, 69, 44 | 54d | 0d |  |
| 098 |  | Typical Sections Analysis | resource dependent | 40d | 2027-09-28 | 2027-11-22 | 64, 65, 66, 67, 68, 69, 44 | 134d | 94d |  |
| 101 |  | Concept Development | resource dependent | 40d | 2027-11-23 | 2028-01-17 | 64, 65, 66, 67, 68, 69, 096, 097, 44 | 54d | 0d |  |
| 103 |  | Drainage Analysis | resource dependent | 40d | 2028-01-18 | 2028-03-13 | 101 | 54d | 14d |  |
| 104 |  | Utility Coordination & Analysis | resource dependent | 40d | 2028-01-18 | 2028-03-13 | 101 | 54d | 14d |  |
| 105 |  | Transportation Management Plan | resource dependent | 40d | 2028-01-18 | 2028-03-13 | 101 | 54d | 14d |  |
| 106 |  | Railroad Coordination | resource dependent | 40d | 2028-01-18 | 2028-03-13 | 101 | 54d | 14d |  |
| 100 |  | Transit Analysis | resource dependent | 40d | 2028-02-07 | 2028-03-31 | 64, 65, 66, 67, 68, 78, 126 | 40d | 0d |  |
| 107 |  | Evaluation Matrix (1st Draft) | resource dependent | 5d | 2028-04-03 | 2028-04-07 | 098, 099, 103, 104, 106, 102, 101, 100, 126, 105, 127 | 40d | 0d |  |
| 108 |  | Construction Cost Estimates (LRE) | resource dependent | 20d | 2028-04-10 | 2028-05-05 | 107 | 50d | 10d |  |
| 109 |  | Right-of-Way Analysis | resource dependent | 20d | 2028-04-10 | 2028-05-05 | 107 | 50d | 10d |  |
| 110 |  | Evaluation Matrix (2nd Draft) | resource dependent | 5d | 2028-05-22 | 2028-05-26 | 108, 109, 128, 129, 130, 131, 132, 133 | 40d | 0d |  |
| 111 |  | Risk Management | resource dependent | 35d | 2028-05-29 | 2028-07-14 | 110 | 106d |  |  |
| 112 |  | Refine Alternatives (based on public input) | resource dependent | 10d | 2028-08-15 | 2028-08-28 | 52 | 0d |  |  |
| 113 |  | Prepare 1st Draft Engineering Reports (Drainage, Utility, Roadway Plans, ITS, Lighting, Pavement, Geotech, PER) | resource dependent | 40d | 2028-08-29 | 2028-10-23 | 52, 112, 78, 110 | 0d |  |  |
| 114 |  | District Review - 1st Draft Engineering Reports | resource dependent | 20d | 2028-10-24 | 2028-11-20 | 113 | 0d |  |  |
| 115 |  | Comment Resolution & Update 1st DRAFT Engineering Reports | resource dependent | 15d | 2028-11-21 | 2028-12-11 | 114 | 0d |  |  |
| 116 |  | Value Engineering Study | resource dependent | 5d | 2028-12-12 | 2028-12-18 | 115, 111 | 0d |  |  |
| 117 |  | Value Engineering Review | resource dependent | 10d | 2029-01-16 | 2029-01-29 | 116 FS+20d | 0d |  | 339 |
| 118 |  | Typical Section Selection | resource dependent | 1d | 2029-01-30 | 2029-01-30 | 117 | 20d |  | 759 |
| 119 |  | Prepare Design Variations and Exceptions | resource dependent | 20d | 2029-01-30 | 2029-02-26 | 117 | 0d |  |  |
| 120 |  | Alternatives Evaluation Complete | resource dependent | 1d | 2029-02-27 | 2029-02-27 | 119 | 0d |  | 712 |
| 121 |  | District Review - 2nd Draft Engineering Reports (Drainage, Utility, Roadway Plans, ITS, Lighting, Pavement, Geotech, PER | resource dependent | 20d | 2029-02-28 | 2029-03-27 | 118, 120, 119 | 0d |  |  |
| 122 |  | OEM Engineering Review | resource dependent | 23d | 2029-03-28 | 2029-04-27 | 121 | 0d |  | 772 |
| 123 |  | District Prepares Responses | resource dependent | 12d | 2029-04-30 | 2029-05-15 | 122 | 0d |  | 773 |
| 124 |  | OEM/District Comment Resolution | resource dependent | 23d | 2029-05-16 | 2029-06-15 | 123 | 0d |  | 774 |

| ID | WBS | Activity | Type | Duration | Start | Finish | Predecessors | Total float | Free float | user_text1 |
| --- | --- | --- | --- | --- | --- | --- | --- | --- | --- | --- |
|  | 4 | **ENVIRONMENTAL ANALYSIS** |  |  | 2027-05-14 | 2029-03-01 |  |  |  |  |
| 126 |  | Environmental GIS Data Collection | resource dependent | 20d | 2027-05-14 | 2027-06-10 | 32 | 211d | 0d |  |
| 127 |  | Environmental GIS Desktop Analysis | resource dependent | 40d | 2027-06-11 | 2027-08-05 | 126 | 211d | 171d |  |
| 128 |  | Data Collection & CRAS | resource dependent | 30d | 2028-04-10 | 2028-05-19 | 107 | 40d | 0d |  |
| 129 |  | Data Collection & Noise Analysis | resource dependent | 30d | 2028-04-10 | 2028-05-19 | 107, 78 | 40d | 0d |  |
| 130 |  | Data Collection & Contamination Screen Evaluation | resource dependent | 30d | 2028-04-10 | 2028-05-19 | 107 | 40d | 0d |  |
| 131 |  | Wetland Delineation and Evaluation | resource dependent | 30d | 2028-04-10 | 2028-05-19 | 107 | 40d | 0d |  |
| 132 |  | Data Collection & Wildlife Survey | resource dependent | 30d | 2028-04-10 | 2028-05-19 | 107 | 40d | 0d |  |
| 133 |  | Essential Fish Habitat Evaluation | resource dependent | 30d | 2028-04-10 | 2028-05-19 | 107 | 40d | 0d |  |
| 134 |  | Determination of Section 4(f) | resource dependent | 30d | 2028-04-10 | 2028-05-19 | 107 | 122d | 0d |  |
| 135 |  | Prepare 1st Draft NRE Report | resource dependent | 25d | 2028-05-22 | 2028-06-23 | 131, 132, 133 | 122d | 0d |  |
| 136 |  | Prepare 1st Draft CRAS | resource dependent | 25d | 2028-05-22 | 2028-06-23 | 128 | 122d | 0d |  |
| 137 |  | Prepare 1st Draft CSER | resource dependent | 25d | 2028-05-22 | 2028-06-23 | 130 | 122d | 0d |  |
| 138 |  | Prepare 1st Draft NSR | resource dependent | 25d | 2028-05-22 | 2028-06-23 | 129 | 122d | 0d |  |
| 139 |  | Prepare Draft Section 4(f) | resource dependent | 25d | 2028-05-22 | 2028-06-23 | 134 | 122d | 0d |  |
| 140 |  | District Review 1st Draft Environmental Reports (NRE, CSER, CRAS, Noise, Section 4(f)) | resource dependent | 20d | 2028-06-26 | 2028-07-21 | 135, 136, 137, 138, 139 | 122d | 0d |  |
| 141 |  | Comment Resolution & Update Draft Environmental Reports | resource dependent | 15d | 2028-07-24 | 2028-08-11 | 140 | 122d | 0d |  |
| 142 |  | OEM Review NRE | resource dependent | 25d | 2028-08-14 | 2028-09-15 | 140, 141 | 122d | 0d |  |
| 143 |  | Finalize CRAS | resource dependent | 10d | 2028-08-14 | 2028-08-25 | 141 | 159d | 0d | 333 |
| 145 |  | Section 106 Effects Complete | resource dependent | 1d | 2028-08-28 | 2028-08-28 | 143 | 159d | 130d | 762 |
| 144 |  | Finalize NRE Report | resource dependent | 10d | 2028-09-18 | 2028-09-29 | 141, 142 | 122d | 86d | 761 |
| 146 |  | Submit NRE to USFWS, NMFS, USACE, and FWS | resource dependent | 1d | 2029-01-30 | 2029-01-30 | 144, 117 | 36d | 0d |  |
| 149 |  | Prepare Conceptual Stage Relocation Plan | resource dependent | 20d | 2029-01-30 | 2029-02-26 | 117 | 29d | 0d |  |
| 147 |  | Informal USFWS Consultation Complete | resource dependent | 22d | 2029-01-31 | 2029-03-01 | 146 | 36d | 7d | 752 |
| 148 |  | Informal NMFS Consultation Complete | resource dependent | 22d | 2029-01-31 | 2029-03-01 | 146 | 36d | 7d | 763 |
| 150 |  | Environmental Analysis Complete | resource dependent | 0d | 2029-02-27 | 2029-02-27 | 145, 149 | 29d | 0d |  |

| ID | WBS | Activity | Type | Duration | Start | Finish | Predecessors | Total float | Free float | user_text1 |
| --- | --- | --- | --- | --- | --- | --- | --- | --- | --- | --- |
|  | 5 | **FINAL ENGINEERING & EA DOCUMENTATION** |  |  | 2029-03-13 | 2030-02-27 |  |  |  |  |
| 152 |  | Prepare Draft EA for Public Availability | resource dependent | 30d | 2029-03-13 | 2029-04-23 | 117, 145, 147, 148, 149, 17 | 29d | 0d |  |
| 153 |  | Planning Consistency Verified | resource dependent | 3d | 2029-04-19 | 2029-04-23 | 152 FF | 29d | 0d | 710 |
| 154 |  | District QC Draft Environment Document | resource dependent | 10d | 2029-04-24 | 2029-05-07 | 152, 153 | 29d | 0d | 713 |
| 155 |  | EA to OEM Initial Review | resource dependent | 20d | 2029-06-18 | 2029-07-13 | 154, 124 | 0d |  | 718 |
| 156 |  | EA to Cooperating Agency Initial Review | resource dependent | 20d | 2029-06-18 | 2029-07-13 | 154, 124 | 0d |  | 716 |
| 157 |  | District Prepares Responses | resource dependent | 10d | 2029-07-16 | 2029-07-27 | 155, 156 | 0d |  | 773 |
| 158 |  | OEM/District Comment Resolution | resource dependent | 15d | 2029-07-30 | 2029-08-17 | 157 | 0d |  | 774 |
| 159 |  | EA to OEM Final Review by PDC | resource dependent | 5d | 2029-08-20 | 2029-08-24 | 158 | 0d |  |  |
| 160 |  | EA OEM Approval Final Review, Legal Review for Section 4(f) and Approval | resource dependent | 20d | 2029-08-27 | 2029-09-21 | 158, 159 | 0d |  | 719 |
| 161 |  | Finalize Engineering & Environmental Reports | resource dependent | 10d | 2029-10-30 | 2029-11-12 | 61 | 10d |  |  |
| 162 |  | Finalize Section 4(f) | resource dependent | 20d | 2029-10-30 | 2029-11-26 | 61 | 0d |  | 751 |
| 163 |  | Finalize PD&E NSR | resource dependent | 5d | 2029-10-30 | 2029-11-05 | 61 | 15d |  | 335 |
| 164 |  | Finalize PER | resource dependent | 5d | 2029-10-30 | 2029-11-05 | 61 | 15d |  | 760 |
| 165 |  | FONSI to OEM Initial Review | resource dependent | 20d | 2029-11-27 | 2029-12-24 | 61, 161, 164, 162, 163 | 0d |  | 731 |
| 166 |  | FONSI to Cooperating Agencies Initial Review | resource dependent | 20d | 2029-11-27 | 2029-12-24 | 61, 161, 162, 163, 164 | 0d |  | 717 |
| 167 |  | District Prepares Responses | resource dependent | 10d | 2029-12-25 | 2030-01-07 | 165, 166 | 0d |  | 773 |
| 168 |  | OEM/District Comment Resolution | resource dependent | 10d | 2030-01-08 | 2030-01-21 | 167 | 0d |  | 774 |
| 169 |  | FONSI OEM Approval Final Review | resource dependent | 20d | 2030-01-22 | 2030-02-18 | 168 | 0d |  | 732 |
| 170 |  | Location Design Concept Acceptance (LDCA) | resource dependent | 0d | 2030-02-19 | 2030-02-19 | 169, 33 | 0d |  | 263 |
| 171 |  | EA and FONSI uploaded to ETDM | resource dependent | 1d | 2030-02-19 | 2030-02-19 | 169, 170 | 5d |  |  |
| 172 |  | Local Design Concept Acceptance Public Notice | resource dependent | 1d | 2030-02-19 | 2030-02-19 | 170 | 0d |  | 736 |
| 173 |  | Interchange Access Request Approval | resource dependent | 5d | 2030-02-20 | 2030-02-26 | 172, 94 | 0d |  | 765 |
| 174 |  | Pass the Torch Meeting | resource dependent | 1d | 2030-02-27 | 2030-02-27 | 172, 171, 173 | 0d |  |  |
