# Planning, PD&E (SEIR) and Design.mpp

Schedule from Primavera P6, 2016-08-01 to 2021-07-08, data date 2016-08-01.
Must finish by 2021-07-08

## Calendars

- Standard: Mon-Sun off.

## Schedule

| ID | WBS | Activity | Duration | Start | Finish | Predecessors | Total float | Free float | Constraint | Stack/Buffer |
| --- | --- | --- | --- | --- | --- | --- | --- | --- | --- | --- |
|  | 1 | **PLANNING ACTIVITIES** |  | 2016-08-01 | 2017-07-17 |  |  |  |  |  |
| 2 |  | District SWAT Planning Meeting (May take place 6 months to 5 years before SWAT Kickoff Meeting) | 1d | 2016-08-01 | 2016-08-01 |  | 0d |  | start on or after 2016-08-01 | 746 |
| 3 |  | District SWAT Strategy Meeting (6 months after the SWAT Planning Meeting when the Tentative Work Program has been submit | 2d | 2017-02-01 | 2017-02-02 | 2 FS+16.38d | 0d |  |  |  |
|  | 1.3 | **ETDM PROGRAMMING SCREEN** |  | 2017-03-03 | 2017-07-17 |  |  |  |  |  |
| 9 |  | ETDM PROGRAMMING SCREEN START/ADVANCE NOTIFICATION | 32d | 2017-03-31 | 2017-05-15 | 6, 7, 8 | 0d |  |  | 700, 224 |
| 10 |  | ETDM Programming Screen Responses | 44d | 2017-05-16 | 2017-07-14 | 9 | 0d |  |  |  |
| 11 |  | ETDM PROGRAMMING PRELIMINARY SUMMARY REPORT PUBLISHED | 1d | 2017-07-17 | 2017-07-17 | 10 | 0d |  |  | 701 |
|  | 1.3.1 | **ETDM Programming Screen Meeting** |  | 2017-03-03 | 2017-03-30 |  |  |  |  |  |
| 6 |  | ETDM Programming Screen PED | 20d | 2017-03-03 | 2017-03-30 | 3 FS+2.5d | 0d |  |  |  |
| 7 |  | ETDM Programming Screen Purpose and Need | 20d | 2017-03-03 | 2017-03-30 | 3 FS+2.5d | 0d |  |  |  |
| 8 |  | Planning Consistency Completion | 5d | 2017-03-03 | 2017-03-09 | 3 FS+2.5d | 15d |  |  | 710 |
|  | 2 | **PRE-PD&E ACTIVITIES** |  | 2017-08-01 | 2018-07-31 |  |  |  |  |  |
| 13 |  | SWAT Kickoff Meeting | 1d | 2017-08-01 | 2017-08-01 | 11 FS+1.25d | 0d |  |  | 747 |
| 14 |  | Assign PD&E Project Manager | 1d | 2017-08-02 | 2017-08-02 | 13 | 0d |  |  | 704 |
|  | 2.3 | **TRAFFIC FORECAST ANALYSIS** |  | 2017-08-03 | 2018-01-11 |  |  |  |  |  |
| 16 |  | Traffic Methodology Meeting | 1d | 2017-08-03 | 2017-08-03 | 7, 14, 13 | 0d |  |  |  |
| 17 |  | Traffic Methodology Memorandum | 10d | 2017-08-04 | 2017-08-17 | 16 | 0d |  |  |  |
| 18 |  | Traffic Data Collection | 20d | 2017-08-18 | 2017-09-14 | 17 | 0d |  |  |  |
| 19 |  | Prepare Traffic Projections | 40d | 2017-09-15 | 2017-11-09 | 18 | 0d |  |  |  |
| 20 |  | Draft Project Traffic Forecast Report | 20d | 2017-11-10 | 2017-12-07 | 19 | 0d |  |  |  |
| 21 |  | FDOT Review - Draft Project Traffic Forecast Report | 15d | 2017-12-08 | 2017-12-28 | 20 | 0d |  |  |  |
| 22 |  | Final Project Traffic Forecast Report | 10d | 2017-12-29 | 2018-01-11 | 21 | 0d |  |  | 757 |
|  | 2.4 | **INTERCHANGE ACCESS REQUEST** |  | 2017-08-03 | 2018-07-13 |  |  |  |  |  |
| 24 |  | Initiate IJR/IMR/SIMR or IOAR | 1d | 2017-08-03 | 2017-08-03 | 9, 14 | 169d | 0d |  |  |
| 25 |  | Prepare MLOU | 5d | 2017-08-04 | 2017-08-10 | 24 | 169d | 0d |  |  |
| 26 |  | DIRC/SPO Review of MLOU | 10d | 2017-08-11 | 2017-08-24 | 25 | 169d | 75d |  |  |
| 27 |  | Develop Alternatives | 30d | 2017-12-08 | 2018-01-18 | 20, 26 | 94d | 0d |  |  |
| 28 |  | Perform Operational Analysis | 30d | 2018-01-19 | 2018-03-01 | 27 | 94d | 0d |  |  |
| 29 |  | Prepare Preliminary IMR/IJR | 45d | 2018-03-02 | 2018-05-03 | 28 | 94d | 0d |  |  |
| 30 |  | DIRC/SPO Review of Preliminary IJR/IMR | 10d | 2018-05-04 | 2018-05-17 | 29 | 94d | 0d |  |  |
| 31 |  | Prepare Final IJR/IMR | 30d | 2018-05-18 | 2018-06-28 | 30 | 94d | 0d |  |  |
| 32 |  | DIRC/SPO Review of Final IJR/IMR | 10d | 2018-06-29 | 2018-07-12 | 31 | 94d | 0d |  |  |
| 33 |  | IJR/IMR Approval | 1d | 2018-07-13 | 2018-07-13 | 32 | 94d |  |  | 765 |

| ID | WBS | Activity | Duration | Start | Finish | Predecessors | Total float | Free float | Constraint | Stack/Buffer |
| --- | --- | --- | --- | --- | --- | --- | --- | --- | --- | --- |
|  | 2.5 | **DESIGN RELATED ACTIVITIES** |  | 2017-09-14 | 2018-01-03 |  |  |  |  |  |
| 35 |  | Design Survey and ROW Mapping | 80d | 2017-09-14 | 2018-01-03 | 14 FS+3.75d | 6d |  |  |  |
| 36 |  | Geotechnical Investigations | 80d | 2017-09-14 | 2018-01-03 | 14 FS+3.75d | 6d |  |  |  |
| 37 |  | Pavement Coring Evaluation Report | 80d | 2017-09-14 | 2018-01-03 | 14 FS+3.75d | 6d |  |  |  |
|  | 2.6 | **DEVELOP SCOPE AND SCHEDULE** |  | 2018-01-12 | 2018-02-09 |  |  |  |  |  |
| 39 |  | Begin PD&E Scope and Schedule | 20d | 2018-01-12 | 2018-02-08 | 11, 22, 35, 36, 37 | 0d |  |  |  |
| 40 |  | PD&E SCOPE AND SCHEDULE COMPLETION | 1d | 2018-02-09 | 2018-02-09 | 39 | 0d |  |  | 703 |
|  | 2.7 | **PROCUREMENT** |  | 2018-02-12 | 2018-07-31 |  |  |  |  |  |
| 42 |  | PD&E Advertisement | 1d | 2018-02-12 | 2018-02-12 | 40 | 0d |  |  | 705 |
| 43 |  | Procurement | 120d | 2018-02-13 | 2018-07-30 | 40, 42 | 0d |  |  |  |
| 44 |  | Notice to Proceed | 1d | 2018-07-31 | 2018-07-31 | 43 | 0d |  | start on or after 2016-04-01 |  |
|  | 3 | **PD&E STUDY** |  | 2018-08-01 | 2020-03-20 |  |  |  |  |  |
|  | 3.1 | **PROJECT MANAGEMENT** |  | 2018-08-01 | 2018-08-09 |  |  |  |  |  |
| 47 |  | SEIR START | 1d | 2018-08-01 | 2018-08-01 | 44 | 0d |  |  | 709 |
| 48 |  | Prepare Project Management Plan | 5d | 2018-08-02 | 2018-08-08 | 47 | 0d |  |  |  |
| 49 |  | Prepare QC Plan | 5d | 2018-08-02 | 2018-08-08 | 47 | 0d |  |  |  |
| 50 |  | Project Kickoff Meeting with FDOT | 1d | 2018-08-09 | 2018-08-09 | 48, 49 | 0d |  |  |  |
|  | 3.2 | **PUBLIC INVOLVEMENT** |  | 2018-08-02 | 2020-01-28 |  |  |  |  |  |
| 52 |  | Prepare Public Involvement Plan | 20d | 2018-08-02 | 2018-08-29 | 47 | 93d | 31d |  |  |
| 53 |  | Public Involvement Data Collection | 45d | 2018-08-10 | 2018-10-11 | 50 | 62d | 0d |  |  |
|  | 3.2.3 | **Prepare for Public Kickoff Meeting** |  | 2018-10-12 | 2018-12-17 |  |  |  |  |  |
| 55 |  | Site Review | 1d | 2018-10-12 | 2018-10-12 | 84 FS-7.5d, 52, 53 | 62d | 0d |  | 365 |
| 56 |  | Newsletter | 20d | 2018-10-15 | 2018-11-09 | 55 | 62d | 0d |  |  |
| 57 |  | Newspaper Ad | 20d | 2018-10-15 | 2018-11-09 | 55 | 62d | 0d |  |  |
| 58 |  | Elected/Appointed/Property Owner Letters | 20d | 2018-10-15 | 2018-11-09 | 55 | 62d | 0d |  |  |
| 59 |  | Presentation/Display Material Review | 15d | 2018-11-12 | 2018-11-30 | 58, 56, 57 | 62d | 0d |  |  |
| 60 |  | Public Kickoff Meeting | 1d | 2018-12-03 | 2018-12-03 | 84, 81, 82, 83, 86, 59 | 62d | 0d |  |  |
| 61 |  | Public Comment Period | 10d | 2018-12-04 | 2018-12-17 | 60 | 62d | 33d |  |  |

| ID | WBS | Activity | Duration | Start | Finish | Predecessors | Total float | Free float | Stack/Buffer |
| --- | --- | --- | --- | --- | --- | --- | --- | --- | --- |
|  | 3.2.4 | **Prepare for Public Information Meeting** |  | 2019-02-01 | 2019-05-17 |  |  |  |  |
| 63 |  | Site Review | 1d | 2019-02-01 | 2019-02-01 | 103 FS-7.5d, 61 | 29d | 0d | 365 |
| 64 |  | Newsletter | 20d | 2019-02-04 | 2019-03-01 | 63 | 29d | 0d |  |
| 65 |  | Newspaper Ad | 20d | 2019-02-04 | 2019-03-01 | 63 | 29d | 0d |  |
| 66 |  | Elected/Appointed/Property Owner Letters | 20d | 2019-02-04 | 2019-03-01 | 63 | 29d | 0d |  |
| 67 |  | Presentation/Display Material Review | 15d | 2019-03-04 | 2019-03-22 | 63, 64, 65, 66 | 29d |  |  |
| 68 |  | Public Information Meeting | 1d | 2019-05-03 | 2019-05-03 | 103 FS+0.62d, 67 | 0d |  | 292 |
| 69 |  | Public Comment Period | 10d | 2019-05-06 | 2019-05-17 | 68 | 0d |  |  |
|  | 3.2.5 | **Prepare for Public Hearing** |  | 2019-09-10 | 2020-01-28 |  |  |  |  |
| 71 |  | Site Review | 20d | 2019-09-10 | 2019-10-07 | 69, 141 FS-10d | 359d | 0d | 366 |
| 72 |  | Newsletter | 20d | 2019-10-08 | 2019-11-04 | 71 | 359d | 0d |  |
| 73 |  | Newspaper Ad | 20d | 2019-10-08 | 2019-11-04 | 71 | 359d | 0d |  |
| 74 |  | Elected/Appointed/Property Owner Letters | 20d | 2019-10-08 | 2019-11-04 | 71 | 359d | 0d |  |
| 75 |  | Presentation/Display Material Review | 15d | 2019-11-05 | 2019-11-25 | 71, 72, 73, 74 | 359d | 20d |  |
| 76 |  | Notice of Public Availability | 15d | 2019-12-24 | 2020-01-13 | 75, 141 FS-0.62d, 113, 114, 33 | 339d | 0d |  |
| 77 |  | Public Hearing | 1d | 2020-01-14 | 2020-01-14 | 76, 75 | 339d | 0d | 262 |
| 78 |  | Public Comment Period | 10d | 2020-01-15 | 2020-01-28 | 77 | 339d | 0d |  |
|  | 3.3 | **ENGINEERING ANALYSIS** |  | 2018-08-10 | 2019-11-29 |  |  |  |  |
|  | 3.3.1 | **Data Collection** |  | 2018-08-10 | 2018-09-20 |  |  |  |  |
| 81 |  | Roadway Data Collection | 30d | 2018-08-10 | 2018-09-20 | 50 | 113d | 51d |  |
| 82 |  | Drainage Data Collection | 30d | 2018-08-10 | 2018-09-20 | 50 | 113d | 51d |  |
| 83 |  | Bridge Data Collection | 30d | 2018-08-10 | 2018-09-20 | 50 | 113d | 51d |  |
| 84 |  | Prepare Base Map | 30d | 2018-08-10 | 2018-09-20 | 50 | 113d | 51d |  |
|  | 3.3.2 | **Traffic Analysis** |  | 2018-08-10 | 2018-12-20 |  |  |  |  |
| 86 |  | Crash Data and Analysis | 20d | 2018-08-10 | 2018-09-06 | 50 | 123d | 61d |  |
| 87 |  | Prepare Capacity Analysis | 30d | 2018-08-10 | 2018-09-20 | 50 | 0d |  |  |
| 88 |  | Draft Project Traffic Analysis Report | 20d | 2018-09-21 | 2018-10-18 | 87 | 0d |  |  |
| 89 |  | FDOT Review - Draft Project Traffic Analysis Report | 15d | 2018-10-19 | 2018-11-08 | 88 | 0d |  |  |
| 90 |  | Final Project Traffic Analysis Report | 10d | 2018-11-09 | 2018-11-22 | 89 | 0d |  | 757 |
| 91 |  | Prepare 18Kip ESALs Traffic Data | 20d | 2018-11-23 | 2018-12-20 | 90 | 206d |  |  |

| ID | WBS | Activity | Duration | Start | Finish | Predecessors | Total float | Free float | Stack/Buffer |
| --- | --- | --- | --- | --- | --- | --- | --- | --- | --- |
|  | 3.3.3 | **Alternative Analysis** |  | 2018-10-19 | 2019-11-29 |  |  |  |  |
| 93 |  | Typical Sections Analysis | 30d | 2018-10-19 | 2018-11-29 | 88 | 65d |  |  |
| 94 |  | Complete Streets/Multi Modal Analysis | 30d | 2018-10-19 | 2018-11-29 | 88 | 65d |  |  |
| 95 |  | Concept Development | 40d | 2018-11-23 | 2019-01-17 | 87, 90, 33 | 0d |  |  |
| 96 |  | Access Management Analysis | 40d | 2018-11-23 | 2019-01-17 | 90 | 30d |  |  |
| 97 |  | Drainage Analysis | 30d | 2019-01-18 | 2019-02-28 | 95 | 0d |  |  |
| 98 |  | Utility Coordination & Analysis | 30d | 2019-01-18 | 2019-02-28 | 95 | 0d |  |  |
| 99 |  | Railroad Coordination | 30d | 2019-01-18 | 2019-02-28 | 95 | 0d |  |  |
| 100 |  | Evaluation Matrix (1st Draft) | 5d | 2019-03-01 | 2019-03-07 | 93, 94, 97, 98, 99, 96, 95 | 0d |  |  |
| 101 |  | Construction Cost Estimates (LRE) | 10d | 2019-03-08 | 2019-03-21 | 100 | 20d |  |  |
| 102 |  | Right-of-Way Analysis | 20d | 2019-03-08 | 2019-04-04 | 100 | 10d |  |  |
| 103 |  | Evaluation Matrix (2nd Draft) | 5d | 2019-04-19 | 2019-04-25 | 101, 102, 116, 117, 118, 119, 120, 121 | 0d |  |  |
| 104 |  | Refine Alternatives (based on public input) | 20d | 2019-05-20 | 2019-06-14 | 69 | 539d |  |  |
| 105 |  | Prepare 1st DRAFT Engineering Reports (Drainage, Utility, Roadway Plans, ITS, Lighting, Pavement, Geotech, PER) | 30d | 2019-05-20 | 2019-06-28 | 69, 22, 90 | 0d |  |  |
| 106 |  | FDOT Review - 1st DRAFT Engineering Reports | 20d | 2019-07-01 | 2019-07-26 | 105 | 0d |  |  |
| 107 |  | Update DRAFT Engineering Reports | 15d | 2019-07-29 | 2019-08-16 | 106 | 0d |  |  |
| 108 |  | VE Study | 5d | 2019-08-19 | 2019-08-23 | 107 | 0d |  |  |
| 109 |  | VE Issues Resolution | 10d | 2019-09-23 | 2019-10-04 | 108 FS+2.5d | 0d |  |  |
| 110 |  | Prepare Typical Section Package | 20d | 2019-10-07 | 2019-11-01 | 109 | 0d |  |  |
| 111 |  | Prepare Design Variations and Exceptions | 20d | 2019-10-07 | 2019-11-01 | 109 | 0d |  |  |
| 112 |  | Prepare Pavement Design Report | 20d | 2019-10-07 | 2019-11-01 | 109, 91 | 0d |  |  |
| 113 |  | Typical Section Selection | 20d | 2019-11-04 | 2019-11-29 | 110, 111, 112 | 0d |  | 759 |
| 114 |  | FDOT Review - 2nd DRAFT Engineering Reports (Drainage, Utility, Roadway Plans, ITS, Lighting, Pavement, Geotech, PER) | 20d | 2019-11-04 | 2019-11-29 | 110 | 355d | 16d |  |
|  | 3.4 | **ENVIRONMENTAL ANALYSIS** |  | 2019-03-08 | 2019-11-04 |  |  |  |  |
| 116 |  | Data Collection & Cultural Resources Assessment Survey | 30d | 2019-03-08 | 2019-04-18 | 100 | 0d |  |  |
| 117 |  | Data Collection & Noise Analysis | 30d | 2019-03-08 | 2019-04-18 | 100 | 0d |  |  |
| 118 |  | Data Collection & Contamination Screen Evaluation | 30d | 2019-03-08 | 2019-04-18 | 100 | 0d |  |  |
| 119 |  | Wetland Delineation and Evaluation | 30d | 2019-03-08 | 2019-04-18 | 100 | 0d |  |  |
| 120 |  | Data Collection & Wildlife Survey | 30d | 2019-03-08 | 2019-04-18 | 100 | 0d |  |  |
| 121 |  | Essential Fish Habitat Evaluation | 30d | 2019-03-08 | 2019-04-18 | 100 | 0d |  |  |
| 122 |  | Determination of Section 4(f) | 15d | 2019-03-08 | 2019-03-28 | 100 | 400d | 0d |  |
| 127 |  | Prepare Draft Section 4(f) Evaluation | 30d | 2019-03-29 | 2019-05-09 | 122 | 400d | 15d |  |
| 123 |  | Prepare 1st Draft Natural Resource Evaluation Report | 30d | 2019-04-19 | 2019-05-30 | 119, 120, 121 | 385d | 0d |  |
| 124 |  | Prepare 1st Draft Cultural Resources Assessment Survey | 30d | 2019-04-19 | 2019-05-30 | 116 | 385d | 0d |  |
| 125 |  | Prepare 1st Draft Contamination Screen Evaluation Report | 30d | 2019-04-19 | 2019-05-30 | 118 | 385d | 0d |  |
| 126 |  | Prepare 1st Draft Noise Study Report | 30d | 2019-04-19 | 2019-05-30 | 117 | 385d | 0d |  |
| 128 |  | FDOT Review 1st DRAFT Environmental Reports (NRE, CSER, CRAS, Noise, Section 4(f)) | 20d | 2019-05-31 | 2019-06-27 | 123, 124, 125, 126, 127 | 385d | 0d |  |
| 129 |  | Update Environmental Reports | 15d | 2019-06-28 | 2019-07-18 | 128 | 385d | 0d |  |
| 130 |  | Finalize Cultural Resources Assessment Survey | 10d | 2019-07-19 | 2019-08-01 | 129 | 385d | 46d | 333 |
| 131 |  | Finalize Natural Resource Evaluation Report | 10d | 2019-07-19 | 2019-08-01 | 129 | 395d | 46d | 761 |
| 132 |  | Submit CRAS to OEM | 20d | 2019-10-07 | 2019-11-01 | 129, 109, 130 | 339d | 0d |  |
| 134 |  | Submit NRE to USFWS | 1d | 2019-10-07 | 2019-10-07 | 109, 131 | 349d | 0d |  |
| 135 |  | Submit NRE to NMFS | 1d | 2019-10-07 | 2019-10-07 | 109, 131 | 349d | 0d |  |
| 138 |  | Prepare Conceptual Relocation Plan | 20d | 2019-10-07 | 2019-11-01 | 109 | 340d | 1d |  |
| 136 |  | Informal USFWS Consultation Complete | 10d | 2019-10-08 | 2019-10-21 | 134 | 349d | 10d | 752 |
| 137 |  | Informal NMFS Consultation Complete | 10d | 2019-10-08 | 2019-10-21 | 135 | 349d | 10d | 763 |
| 133 |  | SHPO Consultation Complete | 1d | 2019-11-04 | 2019-11-04 | 132 | 339d | 0d | 762 |

| ID | WBS | Activity | Duration | Start | Finish | Predecessors | Total float | Free float | Stack/Buffer |
| --- | --- | --- | --- | --- | --- | --- | --- | --- | --- |
|  | 3.5 | **FINAL SEIR DOCUMENTS** |  | 2019-11-05 | 2020-03-20 |  |  |  |  |
| 140 |  | Prepare DRAFT SEIR | 20d | 2019-11-05 | 2019-12-02 | 109, 11, 133, 136, 137, 138 | 339d | 0d |  |
| 141 |  | FDOT Review DRAFT SEIR | 20d | 2019-12-03 | 2019-12-30 | 140 | 339d | 0d | 713 |
| 142 |  | Finalize Engineering & Environmental Reports | 10d | 2020-01-29 | 2020-02-11 | 78 | 344d | 5d | 756 |
| 143 |  | Finalize Section 4(f) Evaluation | 5d | 2020-01-29 | 2020-02-04 | 78 | 339d | 0d | 751 |
| 144 |  | Finalize Noise Study Report | 5d | 2020-01-29 | 2020-02-04 | 78 | 339d | 0d | 335 |
| 145 |  | Finalize Preliminary Engineering Report | 5d | 2020-01-29 | 2020-02-04 | 78 | 349d | 10d | 760 |
| 146 |  | Prepare FINAL SEIR | 10d | 2020-02-05 | 2020-02-18 | 78, 143, 144 | 339d | 0d |  |
| 147 |  | Submit FINAL SEIR to District OEM | 20d | 2020-02-19 | 2020-03-17 | 146, 142, 145 | 339d | 0d |  |
| 148 |  | District Secretary Approval of SEIR | 1d | 2020-03-20 | 2020-03-20 | 147 FS+0.25d | 339d |  | 722 |
|  | 4 | **FINAL DESIGN** |  | 2019-12-02 | 2021-07-08 |  |  |  |  |
|  | 4.1 | **60% (PHASE II) PLANS** |  | 2019-12-02 | 2020-05-12 |  |  |  |  |
| 151 |  | Prepare 60% (Phase II) Plans | 80d | 2019-12-02 | 2020-03-20 | 113 | 0d |  |  |
| 152 |  | Submit 60% Plans & Quantities to FDOT | 1d | 2020-03-23 | 2020-03-23 | 151 | 0d |  | 302 |
| 153 |  | FDOT Review of Phase II Plans | 20d | 2020-03-24 | 2020-04-20 | 152 | 44d | 0d |  |
| 154 |  | Utility Review & Conflict Resolution | 15d | 2020-04-21 | 2020-05-11 | 153 | 44d | 0d |  |
| 155 |  | Prepare and Submit Permit Applications | 15d | 2020-04-21 | 2020-05-11 | 153 | 45d | 1d |  |
| 156 |  | ROW Coordination Meeting 60% | 1d | 2020-05-12 | 2020-05-12 | 154 | 44d | 0d |  |
|  | 4.2 | **90% (PHASE III) PLANS** |  | 2020-05-13 | 2020-09-10 |  |  |  |  |
| 158 |  | Prepare 90% (Phase III) Plans & Quantities | 50d | 2020-05-13 | 2020-07-21 | 155, 156 | 44d | 0d |  |
| 159 |  | Submit 90% Plans & Quantities to FDOT | 1d | 2020-07-22 | 2020-07-22 | 158 | 44d | 0d | 303 |
| 160 |  | FDOT Review of 90% Plans | 20d | 2020-07-23 | 2020-08-19 | 159 | 44d | 0d |  |
| 161 |  | Utility Review & Conflict Resolution | 15d | 2020-08-20 | 2020-09-09 | 160 | 44d | 0d |  |
| 162 |  | ROW Coordination Meeting 90% | 1d | 2020-09-10 | 2020-09-10 | 161 | 44d | 0d |  |

| ID | WBS | Activity | Duration | Start | Finish | Predecessors | Total float | Free float | Stack/Buffer |
| --- | --- | --- | --- | --- | --- | --- | --- | --- | --- |
|  | 4.3 | **100% (PHASE IV) PLANS** |  | 2020-09-11 | 2020-11-20 |  |  |  |  |
| 164 |  | Prepare 100% (Phase IV) Submittal | 30d | 2020-09-11 | 2020-10-22 | 162 | 44d | 0d |  |
| 165 |  | Submit 100% (Phase IV) Submittal to FDOT | 1d | 2020-10-23 | 2020-10-23 | 164 | 44d | 0d | 306 |
| 166 |  | FDOT Review of 100% (Phase IV) Submittal | 20d | 2020-10-26 | 2020-11-20 | 165 | 44d | 0d |  |
|  | 4.4 | **RIGHT OF WAY ACQUISITION** |  | 2019-12-02 | 2021-05-14 |  |  |  |  |
| 168 |  | Determine and Submit ROW Requirements to R/W Office | 60d | 2019-12-02 | 2020-02-21 | 113 | 21d |  | 322 |
| 169 |  | Final ROW Map/Sketches and Legals to R/W Administration | 20d | 2020-03-24 | 2020-04-20 | 152, 168 | 0d |  | 139 |
| 170 |  | Submit Documents to R/W Administration | 1d | 2020-04-21 | 2020-04-21 | 169 | 0d |  | 268 |
| 171 |  | Appraisals Review | 1d | 2020-04-22 | 2020-04-22 | 170 | 0d |  | 143 |
| 172 |  | Perform R/W Appraisals | 120d | 2020-04-23 | 2020-10-07 | 171 | 0d |  | 120 |
| 173 |  | Negotiations and Land Acquisition | 120d | 2020-07-16 | 2020-12-30 | 172 SS+7.5d | 0d |  | 121 |
| 174 |  | Final ROW Order of Taking | 1d | 2020-12-31 | 2020-12-31 | 173 | 0d |  | 273 |
| 175 |  | Condemnation | 60d | 2021-01-01 | 2021-03-25 | 174 | 0d |  | 122 |
| 176 |  | ROW Demo & Clear | 60d | 2021-02-12 | 2021-05-06 | 175 SS+3.75d | 0d |  | 125 |
| 177 |  | ROW Certified | 1d | 2021-05-14 | 2021-05-14 | 176 FS+0.62d | 0d |  | 255 |
|  | 4.5 | **FINAL PLANS** |  | 2020-11-23 | 2021-05-24 |  |  |  |  |
| 179 |  | Plans Completed | 60d | 2020-11-23 | 2021-02-12 | 166 | 44d | 0d | 201 |
| 180 |  | Review Final Plans by Estimate & Construction Office | 20d | 2021-02-15 | 2021-03-12 | 179 | 44d | 0d |  |
| 181 |  | ADA Certification | 1d | 2021-03-22 | 2021-03-22 | 180 FS+0.62d | 44d |  |  |
| 182 |  | All Permits Clear | 1d | 2021-03-22 | 2021-03-22 | 180 FS+0.62d | 44d |  | 222 |
| 183 |  | Utilities Clear | 1d | 2021-03-22 | 2021-03-22 | 180 FS+0.62d | 44d |  | 269 |
| 184 |  | Railroad Clear | 1d | 2021-03-22 | 2021-03-22 | 180 FS+0.62d | 44d |  | 279 |
| 185 |  | Construction Clear | 1d | 2021-03-22 | 2021-03-22 | 180 FS+0.62d | 44d |  | 375 |
| 186 |  | Environmental Clear | 1d | 2021-03-22 | 2021-03-22 | 180 FS+0.62d | 44d |  | 376 |
| 187 |  | Production Date | 1d | 2021-05-24 | 2021-05-24 | 181, 182, 183, 184, 185, 186, 177 FS+0.62d | 0d |  | 204 |

| ID | WBS | Activity | Duration | Start | Finish | Predecessors | Total float | Stack/Buffer |
| --- | --- | --- | --- | --- | --- | --- | --- | --- |
|  | 4.6 | **SPECIFICATIONS PACKAGE** |  | 2021-05-25 | 2021-07-08 |  |  |  |
| 189 |  | Plans to Specs | 1d | 2021-05-25 | 2021-05-25 | 187 | 0d | 226 |
| 190 |  | Prepare Specifications Package | 21d | 2021-05-26 | 2021-06-23 | 187, 189 | 0d | 242 |
| 191 |  | PLANS TO TALLAHASSEE | 1d | 2021-07-08 | 2021-07-08 | 190 FS+1.25d | 0d | 212 |
