# Type 2 CE - Anticipated Primavera 6.0 Schedule

Schedule from Primavera P6, 2026-01-01 to 2029-03-05, data date 2026-01-01.

## Calendars

- Standard: Mon-Fri 08:00-12:00, 13:00-17:00; Sat-Sun off.

## Schedule

| ID | WBS | Activity | Type | Duration | Start | Finish | Predecessors | Total float | Free float | Constraint | user_text1 |
| --- | --- | --- | --- | --- | --- | --- | --- | --- | --- | --- | --- |
|  | 1 | **PLANNING & PRE-PD&E ACTIVITIES** |  |  | 2026-01-01 | 2028-05-12 |  |  |  |  |  |
| 02 |  | START - Pass the Torch from Planning to PD&E / ETDM | resource dependent | 1d | 2026-01-01 | 2026-01-01 |  | 0d |  | start on or after 2026-01-01 | 703 |
| 03 |  | Assign PD&E Project Manager | resource dependent | 6d | 2026-01-02 | 2026-01-09 | 02 | 0d |  |  | 704 |
|  | 3 | **ETDM PROGRAMMING SCREEN** |  |  | 2026-02-09 | 2028-05-12 |  |  |  |  |  |
| 05 |  | ETDM Programming Pre-Screen PED + Purpose and Need | resource dependent | 20d | 2026-02-09 | 2026-03-06 | 03 FS+20d | 0d |  |  | 746 |
| 06 |  | Approval: ETDM Programming Pre-Screen PED + Purpose and Need | resource dependent | 0d | 2026-03-09 | 2026-03-09 | 05 | 0d |  |  |  |
| 07 |  | ETDM/ETAT Programing Screen Start | resource dependent | 32d | 2026-03-09 | 2026-04-21 | 03, 05, 06 | 0d |  |  | 700 |
| 08 |  | Advance Notification | resource dependent | 32d | 2026-03-09 | 2026-04-21 | 03, 05, 06 | 0d |  |  | 224 |
| 09 |  | ETDM Programming Screen Responses | resource dependent | 44d | 2026-04-22 | 2026-06-22 | 07, 08 | 0d |  |  |  |
| 10 |  | ETDM DRAFT Programming Screen Summary Report (w assumed Class of Action) | resource dependent | 1d | 2026-06-23 | 2026-06-23 | 09 | 0d |  |  | 701 |
| 11 |  | ETDM Final Programming Screen Summary Report Published (w final COA) | resource dependent | 10d | 2028-05-01 | 2028-05-12 | 10, 144 | 34d | 0d |  | 702 |
|  | 4 | **DEVELOP SCOPE AND SCHEDULE** |  |  | 2026-06-24 | 2026-07-21 |  |  |  |  |  |
| 13 |  | Initial PD&E Phase Scope (Stage 1) and Schedule Complete | resource dependent | 20d | 2026-06-24 | 2026-07-21 | 10 | 0d |  |  | 164 |
|  | 5 | **PROCUREMENT** |  |  | 2026-07-22 | 2027-01-15 |  |  |  |  |  |
| 15 |  | PD&E Phase Advertisement | resource dependent | 1d | 2026-07-22 | 2026-07-22 | 13 | 0d |  |  | 705 |
| 16 |  | Procurement | resource dependent | 120d | 2026-07-23 | 2027-01-06 | 15 | 0d |  |  |  |
| 17 |  | Final PD&E Phase Scope (Stage 3) | resource dependent | 5d | 2027-01-07 | 2027-01-13 | 16 | 0d |  |  | 164 |
| 18 |  | PD&E Phase Contract Executed | resource dependent | 1d | 2027-01-14 | 2027-01-14 | 17 | 0d |  |  | 239 |
| 19 |  | Notice to Proceed | resource dependent | 1d | 2027-01-15 | 2027-01-15 | 17, 18 | 0d |  | start on or after 2016-04-01 | 234 |
|  | 2 | **PD&E PHASE** |  |  | 2027-01-15 | 2029-03-05 |  |  |  |  |  |
|  | 1 | **PROJECT MANAGEMENT** |  |  | 2027-01-15 | 2028-05-15 |  |  |  |  |  |
| 22 |  | Anticipated PD&E Phase Start (Type 2 CE) | resource dependent | 1d | 2027-01-15 | 2027-01-15 | 19 FS-1d | 0d |  |  | 777 |
| 23 |  | Prepare Project Management Plan | resource dependent | 5d | 2027-01-18 | 2027-01-22 | 22 | 0d |  |  |  |
| 24 |  | Review Local Plans to ensure Planning Consistency | resource dependent | 3d | 2027-01-18 | 2027-01-20 | 22 | 2d |  |  |  |
| 25 |  | Prepare QC Plan | resource dependent | 5d | 2027-01-18 | 2027-01-22 | 22 | 0d |  |  |  |
| 26 |  | Project Kickoff Meeting with FDOT | resource dependent | 1d | 2027-01-25 | 2027-01-25 | 23, 25, 24 | 0d |  |  |  |
| 27 |  | Type 2 CE Start | resource dependent | 0d | 2028-05-15 | 2028-05-15 | 11 | 205d |  |  | 706 |

| ID | WBS | Activity | Type | Duration | Start | Finish | Predecessors | Total float | Free float | user_text1 |
| --- | --- | --- | --- | --- | --- | --- | --- | --- | --- | --- |
|  | 2 | **PUBLIC INVOLVEMENT** |  |  | 2027-01-18 | 2028-09-08 |  |  |  |  |
| 29 |  | Prepare Public Involvement Plan | resource dependent | 20d | 2027-01-18 | 2027-02-12 | 19 | 31d |  | 748 |
| 30 |  | Public Involvement Data Collection | resource dependent | 45d | 2027-01-26 | 2027-03-29 | 26 | 0d |  |  |
|  | 3 | **Prepare for Public Kickoff Meeting** |  |  | 2027-03-30 | 2027-06-04 |  |  |  |  |
| 32 |  | Site Review | resource dependent | 1d | 2027-03-30 | 2027-03-30 | 29, 30 | 0d |  | 365 |
| 33 |  | Newsletter | resource dependent | 20d | 2027-03-31 | 2027-04-27 | 32 | 2d |  |  |
| 34 |  | Prepare FAR/ FDOT Website (Newspaper optional) | resource dependent | 22d | 2027-03-31 | 2027-04-29 | 32 | 0d |  |  |
| 35 |  | Prepare Elected/Appointed/Property Owner Notifications | resource dependent | 20d | 2027-03-31 | 2027-04-27 | 32 | 2d |  |  |
| 36 |  | Presentation/Display Material Review | resource dependent | 15d | 2027-04-30 | 2027-05-20 | 35, 33, 34 | 0d |  |  |
| 37 |  | Public Kickoff Meeting | resource dependent | 1d | 2027-05-21 | 2027-05-21 | 67, 36, 63 | 0d |  | 292 |
| 38 |  | Public Comment Period | resource dependent | 10d | 2027-05-24 | 2027-06-04 | 37 | 0d |  |  |
|  | 4 | **Prepare for Public Meeting / Workshop** |  |  | 2027-08-03 | 2027-11-29 |  |  |  |  |
| 40 |  | Site Review | resource dependent | 1d | 2027-08-03 | 2027-08-03 | 104 FS-60d, 38 | 38d | 0d | 365 |
| 41 |  | Newsletter | resource dependent | 20d | 2027-08-04 | 2027-08-31 | 40 | 38d | 0d |  |
| 42 |  | Prepare FAR/ FDOT Website (Newspaper optional) | resource dependent | 20d | 2027-08-04 | 2027-08-31 | 40 | 38d | 0d |  |
| 43 |  | Prepare Elected/Appointed/Property Owner Notifications | resource dependent | 20d | 2027-08-04 | 2027-08-31 | 40 | 38d | 0d |  |
| 44 |  | Presentation/Display Material Review | resource dependent | 15d | 2027-09-01 | 2027-09-21 | 40, 41, 42, 43 | 38d |  |  |
| 45 |  | Public Meeting / Workshop | resource dependent | 1d | 2027-11-15 | 2027-11-15 | 104 FS+5d, 44, 83 | 0d |  | 292 or 711 |
| 46 |  | Public Comment Period | resource dependent | 10d | 2027-11-16 | 2027-11-29 | 45 | 0d |  |  |
|  | 5 | **Prepare for Public Hearing** |  |  | 2028-04-03 | 2028-09-08 |  |  |  |  |
| 48 |  | Site Review | resource dependent | 20d | 2028-04-03 | 2028-04-28 | 46, 149 FS-60d | 34d | 0d | 366 |
| 49 |  | Newsletter | resource dependent | 20d | 2028-05-01 | 2028-05-26 | 48 | 34d | 0d |  |
| 50 |  | Prepare Newspaper/ FAR/ FDOT Website Notice | resource dependent | 20d | 2028-05-01 | 2028-05-26 | 48 | 34d | 0d |  |
| 51 |  | Prepare Elected/Appointed/Property Owner Notifications | resource dependent | 20d | 2028-05-01 | 2028-05-26 | 48 | 34d | 0d |  |
| 52 |  | Presentation/Display Material Review | resource dependent | 15d | 2028-05-29 | 2028-06-16 | 48, 49, 50, 51 | 34d |  |  |
| 53 |  | Document Available for Public Review | resource dependent | 15d | 2028-08-04 | 2028-08-24 | 52, 149 FS-5d, 118, 88 | 0d |  |  |
| 54 |  | Public Hearing | resource dependent | 1d | 2028-08-25 | 2028-08-25 | 53, 52 | 0d |  | 262 |
| 55 |  | Public Comment Period | resource dependent | 10d | 2028-08-28 | 2028-09-08 | 54 | 0d |  |  |

| ID | WBS | Activity | Type | Duration | Start | Finish | Predecessors | Total float | Free float | user_text1 |
| --- | --- | --- | --- | --- | --- | --- | --- | --- | --- | --- |
|  | 3 | **ENGINEERING ANALYSIS** |  |  | 2027-01-18 | 2028-08-03 |  |  |  |  |
|  | 1 | **Data Collection** |  |  | 2027-01-26 | 2027-03-08 |  |  |  |  |
| 58 |  | Roadway Data Collection | resource dependent | 30d | 2027-01-26 | 2027-03-08 | 26 | 78d | 0d |  |
| 59 |  | Drainage Data Collection | resource dependent | 30d | 2027-01-26 | 2027-03-08 | 26 | 78d | 0d |  |
| 60 |  | Bridge Data Collection | resource dependent | 30d | 2027-01-26 | 2027-03-08 | 26 | 78d | 0d |  |
| 61 |  | Geotechnical Data Collection | resource dependent | 30d | 2027-01-26 | 2027-03-08 | 26 | 78d | 0d |  |
| 62 |  | Topographic Survey and ROW Mapping | resource dependent | 30d | 2027-01-26 | 2027-03-08 | 26 | 78d | 0d |  |
| 63 |  | Prepare Base Map | resource dependent | 30d | 2027-01-26 | 2027-03-08 | 26 | 53d |  |  |
|  | 2 | **Traffic Analysis** |  |  | 2027-01-18 | 2027-06-17 |  |  |  |  |
| 65 |  | Traffic Methodology Meeting | resource dependent | 1d | 2027-01-18 | 2027-01-18 | 19 | 63d | 0d |  |
| 66 |  | Traffic Methodology Memorandum | resource dependent | 10d | 2027-01-19 | 2027-02-01 | 65 | 63d | 58d |  |
| 67 |  | Forecasting and Analysis | resource dependent | 23d | 2027-01-26 | 2027-02-25 | 26 | 5d | 0d |  |
| 68 |  | Prepare Traffic Projections | resource dependent | 20d | 2027-02-26 | 2027-03-25 | 67 | 5d | 0d |  |
| 69 |  | Prepare Capacity Analysis | resource dependent | 20d | 2027-03-26 | 2027-04-22 | 68 | 5d | 0d |  |
| 70 |  | Draft Traffic Analysis Report | resource dependent | 20d | 2027-04-23 | 2027-05-20 | 69, 66 | 5d | 0d |  |
| 71 |  | District Review - Draft Traffic Analysis Report | resource dependent | 15d | 2027-05-21 | 2027-06-10 | 70 | 5d | 0d |  |
| 72 |  | Final Traffic Analysis Report | resource dependent | 5d | 2027-06-11 | 2027-06-17 | 71 | 5d | 0d | 757 |
|  | 3 | **Interchange Access Request** |  |  | 2027-01-18 | 2028-01-17 |  |  |  |  |
| 74 |  | Initiate IAR | resource dependent | 1d | 2027-01-18 | 2027-01-18 | 19 | 54d | 0d |  |
| 75 |  | Prepare MLOU | resource dependent | 10d | 2027-01-19 | 2027-02-01 | 74 | 54d | 0d |  |
| 76 |  | DIRC/SPO Review of MLOU | resource dependent | 15d | 2027-02-02 | 2027-02-22 | 75 | 54d | 0d |  |
| 77 |  | FHWA Review of MLOU | resource dependent | 20d | 2027-02-23 | 2027-03-22 | 76 | 54d |  |  |
| 78 |  | Develop Alternatives | resource dependent | 30d | 2027-06-07 | 2027-07-16 | 38, 77 | 0d |  |  |
| 79 |  | Perform Operational Analysis | resource dependent | 20d | 2027-07-19 | 2027-08-13 | 78 | 0d |  |  |
| 80 |  | Prepare Preliminary IAR | resource dependent | 20d | 2027-08-16 | 2027-09-10 | 79 | 0d |  |  |
| 81 |  | DIRC/SPO Review of Preliminary IAR | resource dependent | 10d | 2027-09-13 | 2027-09-24 | 80 | 0d |  |  |
| 82 |  | Comment Resolution & Update Preliminary IAR | resource dependent | 15d | 2027-09-27 | 2027-10-15 | 81 | 0d |  |  |
| 83 |  | FHWA Review of Preliminary IAR | resource dependent | 20d | 2027-10-18 | 2027-11-12 | 82 | 0d |  |  |
| 84 |  | Prepare Final IAR | resource dependent | 10d | 2027-11-15 | 2027-11-26 | 83 | 143d | 0d |  |
| 85 |  | DIRC/SPO Review of Final IAR | resource dependent | 10d | 2027-11-29 | 2027-12-10 | 84 | 143d | 0d |  |
| 86 |  | Comment Resolution & Update Final IAR | resource dependent | 5d | 2027-12-13 | 2027-12-17 | 85 | 143d | 0d |  |
| 87 |  | FHWA/SPO Review of IAR | resource dependent | 20d | 2027-12-20 | 2028-01-14 | 86 | 143d | 0d |  |
| 88 |  | Safety Operations & Engineering Approval | resource dependent | 1d | 2028-01-17 | 2028-01-17 | 87 | 143d |  |  |

| ID | WBS | Activity | Type | Duration | Start | Finish | Predecessors | Total float | Free float | user_text1 |
| --- | --- | --- | --- | --- | --- | --- | --- | --- | --- | --- |
|  | 4 | **Alternative Analysis** |  |  | 2027-03-09 | 2028-08-03 |  |  |  |  |
| 091 |  | Structure Analysis | resource dependent | 30d | 2027-03-09 | 2027-04-19 | 58, 59, 60, 61, 62 | 108d | 103d |  |
| 093 |  | Complete Streets/Multi Modal Analysis | resource dependent | 30d | 2027-05-21 | 2027-07-01 | 70, 63, 58, 59, 60, 61, 62, 120 | 55d | 50d |  |
| 094 |  | Transit Analysis | resource dependent | 30d | 2027-05-21 | 2027-07-01 | 58, 59, 60, 61, 62, 70, 120 | 55d | 50d |  |
| 090 |  | Roadway Analysis | resource dependent | 30d | 2027-06-07 | 2027-07-16 | 58, 59, 60, 61, 62, 38 | 44d | 39d |  |
| 092 |  | Typical Sections Analysis | resource dependent | 30d | 2027-06-07 | 2027-07-16 | 70, 58, 59, 60, 61, 62, 63, 120, 38 | 44d | 39d |  |
| 095 |  | Concept Development | resource dependent | 30d | 2027-06-18 | 2027-07-29 | 69, 72, 63, 58, 59, 60, 61, 62, 120 | 5d | 0d |  |
| 096 |  | Access Management Analysis | resource dependent | 30d | 2027-06-18 | 2027-07-29 | 72 | 35d | 30d |  |
| 097 |  | Drainage Analysis | resource dependent | 30d | 2027-07-30 | 2027-09-09 | 095 | 5d | 0d |  |
| 098 |  | Utility Coordination & Analysis | resource dependent | 30d | 2027-07-30 | 2027-09-09 | 095 | 5d | 0d |  |
| 099 |  | Transportation Management Plan | resource dependent | 30d | 2027-07-30 | 2027-09-09 | 095 | 5d | 0d |  |
| 100 |  | Railroad Coordination | resource dependent | 30d | 2027-07-30 | 2027-09-09 | 095 | 5d | 0d |  |
| 101 |  | Evaluation Matrix (1st Draft) | resource dependent | 5d | 2027-09-10 | 2027-09-16 | 092, 093, 097, 098, 100, 096, 095, 094, 120, 090, 091, 099, 121 | 5d | 0d |  |
| 102 |  | Construction Cost Estimates (LRE) | resource dependent | 10d | 2027-09-17 | 2027-09-30 | 101 | 17d | 12d |  |
| 103 |  | Right-of-Way Analysis | resource dependent | 10d | 2027-09-17 | 2027-09-30 | 101 | 17d | 12d |  |
| 104 |  | Evaluation Matrix (2nd Draft) | resource dependent | 5d | 2027-10-19 | 2027-10-25 | 102, 103, 122, 123, 124, 125, 126, 127 | 5d | 0d |  |
| 105 |  | Risk Management | resource dependent | 30d | 2027-10-26 | 2027-12-06 | 104 | 5d |  |  |
| 106 |  | Refine Alternatives (based on public input) | resource dependent | 10d | 2027-11-30 | 2027-12-13 | 46 | 0d |  |  |
| 107 |  | Prepare 1st Draft Engineering Reports (Drainage, Utility, Roadway Plans, ITS, Lighting, Pavement, Geotech, PER) | resource dependent | 24d | 2027-12-14 | 2028-01-14 | 46, 72, 104, 106, 105 | 0d |  |  |
| 108 |  | Comment Resolution & District Review - 1st DRAFT Engineering Reports | resource dependent | 20d | 2028-01-17 | 2028-02-11 | 107 | 0d |  |  |
| 109 |  | Update 1st Draft Engineering Reports | resource dependent | 10d | 2028-02-14 | 2028-02-25 | 108 | 0d |  |  |
| 110 |  | Value Engineering Study | resource dependent | 5d | 2028-02-28 | 2028-03-03 | 109 | 0d |  |  |
| 111 |  | Value Engineering Review | resource dependent | 10d | 2028-03-20 | 2028-03-31 | 110 FS+10d | 0d |  | 339 |
| 112 |  | Typical Section Selection | resource dependent | 1d | 2028-04-03 | 2028-04-03 | 111 | 10d |  | 759 |
| 113 |  | Prepare Design Variations and Exceptions | resource dependent | 10d | 2028-04-03 | 2028-04-14 | 111 | 0d |  |  |
| 114 |  | Alternatives Evaluation Complete | resource dependent | 1d | 2028-04-17 | 2028-04-17 | 113 | 0d |  | 712 |
| 115 |  | District Review - 2nd Draft Engineering Reports (Drainage, Utility, Roadway Plans, ITS, Lighting, Pavement, Geotech, PER | resource dependent | 20d | 2028-04-18 | 2028-05-15 | 112, 114, 113 | 0d |  |  |
| 116 |  | OEM Engineering Review | resource dependent | 23d | 2028-05-16 | 2028-06-15 | 115 | 0d |  | 772 |
| 117 |  | District Prepare Responses | resource dependent | 12d | 2028-06-16 | 2028-07-03 | 116 | 0d |  | 773 |
| 118 |  | OEM/District Comment Resolution | resource dependent | 23d | 2028-07-04 | 2028-08-03 | 117 | 0d |  | 774 |

| ID | WBS | Activity | Type | Duration | Start | Finish | Predecessors | Total float | Free float | user_text1 |
| --- | --- | --- | --- | --- | --- | --- | --- | --- | --- | --- |
|  | 4 | **ENVIRONMENTAL ANALYSIS** |  |  | 2027-01-26 | 2028-05-03 |  |  |  |  |
| 120 |  | Environmental GIS Data Collection | resource dependent | 15d | 2027-01-26 | 2027-02-15 | 26 | 93d | 68d |  |
| 121 |  | Environmental GIS Desktop Analysis | resource dependent | 30d | 2027-07-30 | 2027-09-09 | 120, 095 | 5d | 0d |  |
| 122 |  | Data Collection & CRAS | resource dependent | 22d | 2027-09-17 | 2027-10-18 | 101 | 5d | 0d |  |
| 123 |  | Data Collection & Noise Analysis | resource dependent | 22d | 2027-09-17 | 2027-10-18 | 101, 72 | 5d | 0d |  |
| 124 |  | Data Collection & Contamination Screen Evaluation | resource dependent | 22d | 2027-09-17 | 2027-10-18 | 101 | 5d | 0d |  |
| 125 |  | Wetland Delineation and Evaluation | resource dependent | 22d | 2027-09-17 | 2027-10-18 | 101 | 5d | 0d |  |
| 126 |  | Data Collection & Wildlife Survey | resource dependent | 22d | 2027-09-17 | 2027-10-18 | 101 | 5d | 0d |  |
| 127 |  | Essential Fish Habitat Evaluation | resource dependent | 22d | 2027-09-17 | 2027-10-18 | 101 | 5d | 0d |  |
| 128 |  | Determination of Section 4(f) | resource dependent | 22d | 2027-09-17 | 2027-10-18 | 101 | 60d | 0d |  |
| 129 |  | Prepare 1st Draft NRE Report | resource dependent | 22d | 2027-10-19 | 2027-11-17 | 125, 126, 127 | 68d | 8d |  |
| 130 |  | Prepare 1st Draft CRAS | resource dependent | 22d | 2027-10-19 | 2027-11-17 | 122 | 68d | 8d |  |
| 131 |  | Prepare 1st Draft CSER | resource dependent | 22d | 2027-10-19 | 2027-11-17 | 124 | 68d | 8d |  |
| 132 |  | Prepare 1st Draft NSR | resource dependent | 22d | 2027-10-19 | 2027-11-17 | 123 | 68d | 8d |  |
| 133 |  | Prepare Draft Section 4(f) | resource dependent | 30d | 2027-10-19 | 2027-11-29 | 128 | 60d | 0d |  |
| 134 |  | District Review 1st Draft Environmental Reports (NRE, CSER, CRAS, Noise, Section 4(f)) | resource dependent | 20d | 2027-11-30 | 2027-12-27 | 129, 130, 131, 132, 133 | 60d | 0d |  |
| 135 |  | Comment Resolution & Update Draft Environmental Reports | resource dependent | 15d | 2027-12-28 | 2028-01-17 | 134 | 60d | 0d |  |
| 136 |  | OEM Review NRE | resource dependent | 25d | 2028-01-18 | 2028-02-21 | 135 | 60d | 0d |  |
| 137 |  | Finalize CRAS | resource dependent | 10d | 2028-01-18 | 2028-01-31 | 135 | 107d | 0d | 333 |
| 139 |  | Section 106 Effects Complete | resource dependent | 1d | 2028-02-01 | 2028-02-01 | 137 | 107d | 73d | 762 |
| 138 |  | Finalize NRE Report | resource dependent | 10d | 2028-02-22 | 2028-03-06 | 136 | 60d | 19d | 761 |
| 140 |  | Submit NRE to USFWS, NMFS, USACE, and FWS | resource dependent | 1d | 2028-04-03 | 2028-04-03 | 111, 138 | 41d | 0d |  |
| 143 |  | Prepare Conceptual Stage Relocation Plan | resource dependent | 20d | 2028-04-03 | 2028-04-28 | 111 | 34d | 0d |  |
| 141 |  | Informal USFWS Consultation Complete | resource dependent | 22d | 2028-04-04 | 2028-05-03 | 140 | 41d | 7d | 752 |
| 142 |  | Informal NMFS Consultation Complete | resource dependent | 22d | 2028-04-04 | 2028-05-03 | 140 | 41d | 7d | 763 |
| 144 |  | Environmental Analysis Complete | resource dependent | 0d | 2028-05-01 | 2028-05-01 | 143 | 34d | 0d |  |

| ID | WBS | Activity | Type | Duration | Start | Finish | Predecessors | Total float | Free float | user_text1 |
| --- | --- | --- | --- | --- | --- | --- | --- | --- | --- | --- |
|  | 5 | **FINAL ENGINEERING & TYPE 2 CE DOCUMENTATION** |  |  | 2027-01-18 | 2029-03-05 |  |  |  |  |
| 146 |  | Planning Consistency Verified | resource dependent | 1d | 2027-01-18 | 2027-01-18 | 19 | 378d | 344d | 710 |
| 147 |  | Prepare DRAFT Type 2 CE for Public Availability | resource dependent | 20d | 2028-05-15 | 2028-06-09 | 111, 11, 139, 141, 142, 143, 146 | 34d | 0d |  |
| 148 |  | Planning Consistency Verified | resource dependent | 3d | 2028-06-07 | 2028-06-09 | 147 FF | 34d | 0d | 710 |
| 149 |  | District Review Draft Environmental Document | resource dependent | 10d | 2028-06-12 | 2028-06-23 | 147, 148 | 34d | 0d | 713 |
| 150 |  | Finalize Engineering & Environmental Reports | resource dependent | 10d | 2028-09-11 | 2028-09-22 | 55 | 0d |  |  |
| 151 |  | Finalize Section 4(f) | resource dependent | 5d | 2028-09-11 | 2028-09-15 | 55 | 5d |  | 751 |
| 152 |  | Finalize PD&E NSR | resource dependent | 5d | 2028-09-11 | 2028-09-15 | 55 | 5d |  | 335 |
| 153 |  | Finalize PER | resource dependent | 5d | 2028-09-11 | 2028-09-15 | 55 | 15d |  | 760 |
| 154 |  | Prepare DRAFT Type 2 CE for OEM Signature | resource dependent | 10d | 2028-09-25 | 2028-10-06 | 55, 151, 152, 150 | 0d |  |  |
| 155 |  | District Review DRAFT Type 2 CE | resource dependent | 10d | 2028-10-09 | 2028-10-20 | 153, 154 | 0d |  |  |
| 156 |  | District Consultant Resolution | resource dependent | 15d | 2028-10-23 | 2028-11-10 | 155 | 0d |  |  |
| 157 |  | TYPE 2 CE OEM Initial Review | resource dependent | 20d | 2028-11-13 | 2028-12-08 | 155, 156 | 0d |  | 722 |
| 158 |  | TYPE 2 CE Cooperating Agency Initial Review | resource dependent | 20d | 2028-11-13 | 2028-12-08 | 155, 156 | 0d |  | 726 |
| 159 |  | District Prepares Responses | resource dependent | 10d | 2028-12-11 | 2028-12-22 | 157, 158 | 0d |  | 773 |
| 160 |  | OEM/District Comment Resolution | resource dependent | 15d | 2028-12-25 | 2029-01-12 | 159 | 0d |  | 774 |
| 161 |  | Type 2 CE to OEM Final Review by PDC | resource dependent | 10d | 2029-01-15 | 2029-01-26 | 160 | 0d |  |  |
| 162 |  | Type 2 CE OEM Final Review & Approval | resource dependent | 20d | 2029-01-29 | 2029-02-23 | 160, 161 | 0d |  | 733 |
| 163 |  | Location Design Concept Acceptance (LDCA) | resource dependent | 0d | 2029-02-26 | 2029-02-26 | 162, 27 | 0d |  | 263 |
| 164 |  | LDCA Public + Agency/ETAT Notice | resource dependent | 1d | 2029-02-26 | 2029-02-26 | 162, 163 | 4d |  | 736 |
| 165 |  | Interchange Access Request Approval | resource dependent | 5d | 2029-02-26 | 2029-03-02 | 163, 88 | 0d |  | 765 |
| 166 |  | Pass the Torch Meeting | resource dependent | 1d | 2029-03-05 | 2029-03-05 | 164, 165 | 0d |  |  |
